# HRA Project Plan

Schedule from MS Project, 2011-10-31 to 2012-10-26, A marks actual dates.
Microsoft

## Calendars

- Standard: Mon-Fri 08:00-12:00, 13:00-17:00; Sat-Sun off. Exceptions (off unless hours are given): 2011-11-24 (Thanksgiving Day), 2011-11-25 (Thanksgiving Friday), 2011-12-23 (Special MIT Holiday 1), 2011-12-26 (Christmas Day Observed), 2011-12-30 (Special MIT Holiday 2), 2012-01-02 (New Years Day Observed), 2012-01-16 (Martin Luther King Birthday), 2012-02-20 (Presidents Day).

## Resources

| Resource |
| --- |
| Ross |
| Jonathan |
| Robin |
| Janet |

## Schedule

| ID | WBS | Task | Type | Duration | Start | Finish | Predecessors | Complete | Remaining | Total slack | Constraint | Resources | Work | Actual work |
| --- | --- | --- | --- | --- | --- | --- | --- | --- | --- | --- | --- | --- | --- | --- |
| 1 | 1 | **Housing Replacement Analysis Project** |  | 252d | 2011-10-31 A | 2012-10-26 |  | 27% | 184.89d | 0d |  |  | 4464.4h | 1181.2h |
| 2 | 1.1 | Project Kickoff Meeting |  | 1d | 2011-10-31 | 2011-10-31 |  |  |  | 227d |  |  |  |  |
| 3 | 1.2 | **Discovery Phase (as-is)** |  | 183d | 2011-11-04 A | 2012-07-27 |  | 73% | 48.62d | 65d |  |  | 1550.8h | 1181.2h |
| 4 | 1.2.1 | **Business Justification** |  | 20d | 2011-11-04 A | 2011-12-06 A | 2 | 100% |  |  |  |  | 136h | 136h |
| 5 | 1.2.1.1 | Write Business Justification |  | 10d | 2011-11-14 A | 2011-11-25 A | 6 | 100% |  |  | start no earlier than 2011-11-01 | Jonathan | 80h | 80h |
| 6 | 1.2.1.2 | Review Business Justification |  | 6d | 2011-11-04 A | 2011-11-11 A |  | 100% |  |  | finish no earlier than 2011-11-11 | Jonathan | 48h | 48h |
| 7 | 1.2.1.3 | Obtain Approval from Project Team |  | 1d | 2011-11-29 A | 2011-11-29 A | 5, 6 | 100% |  |  | start no earlier than 2011-11-29 | Jonathan | 8h | 8h |
| 8 | 1.2.1.4 | Obtain Approval from Project Sponsors | milestone | 0d | 2011-12-06 A | 2011-12-06 A | 7 | 100% |  |  | start no earlier than 2011-12-06 | Jonathan |  |  |
| 9 | 1.2.1.5 | Business Justification completed | milestone | 0d | 2011-12-06 A | 2011-12-06 A | 8 | 100% |  |  |  | Jonathan |  |  |
| 10 | 1.2.2 | **Project Scope Document** |  | 19d | 2011-11-07 A | 2011-12-06 A | 2 | 100% |  |  |  |  | 56h | 56h |
| 11 | 1.2.2.1 | Write Project Scope Document |  | 5d | 2011-11-07 A | 2011-11-11 A |  | 100% |  |  | finish no earlier than 2011-11-11 | Jonathan | 40h | 40h |
| 12 | 1.2.2.2 | Review Project Scope Document |  | 1d | 2011-11-18 A | 2011-11-18 A | 11 | 100% |  |  | finish no earlier than 2011-11-18 | Jonathan | 8h | 8h |
| 13 | 1.2.2.3 | Obtain Approval from Project Team |  | 1d | 2011-11-29 A | 2011-11-29 A |  | 100% |  |  | start no earlier than 2011-11-29 | Jonathan | 8h | 8h |
| 14 | 1.2.2.4 | Obtain Approval from Project Sponsors | milestone | 0d | 2011-12-06 A | 2011-12-06 A |  | 100% |  |  | start no earlier than 2011-12-06 | Jonathan |  |  |
| 15 | 1.2.2.5 | Project Scope completed | milestone | 0d | 2011-12-06 A | 2011-12-06 A |  | 100% |  |  | start no earlier than 2011-12-06 | Jonathan |  |  |
| 16 | 1.2.3 | **Discovery Meetings** |  | 103d | 2011-12-15 A | 2012-05-15 | 4, 10 | 98% | 1.67d | 94d |  |  | 808h | 804.8h |
| 17 | 1.2.3.1 | **Housing / Lottery** |  | 94d | 2011-12-15 A | 2012-05-02 A |  | 100% |  |  |  |  | 12.8h | 12.8h |
| 18 | 1.2.3.1.1 | Freshman (new to the Institute) |  | 2d | 2011-12-15 A | 2011-12-16 A |  | 100% |  |  | start no earlier than 2011-12-15 | Ross [40%] | 6.4h | 6.4h |
| 19 | 1.2.3.1.2 | Upperclassman |  | 1d | 2012-04-09 A | 2012-04-09 A |  | 100% |  |  | start no earlier than 2012-04-09 | Ross [40%] | 3.2h | 3.2h |
| 20 | 1.2.3.1.3 | Graduate Students |  | 1d | 2012-05-02 A | 2012-05-02 A |  | 100% |  |  | start no earlier than 2012-05-02 | Janet [40%] | 3.2h | 3.2h |
| 21 | 1.2.3.2 | **Housing filemaker Databases** |  | 10d | 2012-02-06 A | 2012-02-17 A |  | 100% |  |  |  |  | 232h | 232h |
| 22 | 1.2.3.2.1 | Master Blaster |  | 5d | 2012-02-06 A | 2012-02-10 A |  | 100% |  |  | start no earlier than 2012-02-06 | Janet | 40h | 40h |
| 23 | 1.2.3.2.2 | UG Confirmation |  | 5d | 2012-02-06 A | 2012-02-10 A |  | 100% |  |  | start no earlier than 2012-02-06 | Ross [40%] | 16h | 16h |
| 24 | 1.2.3.2.3 | Conference / Guest |  | 5d | 2012-02-06 A | 2012-02-10 A |  | 100% |  |  | start no earlier than 2012-02-06 | Ross [40%] | 16h | 16h |
| 25 | 1.2.3.2.4 | Vacancy |  | 5d | 2012-02-13 A | 2012-02-17 A |  | 100% |  |  | start no earlier than 2012-02-13 | Janet | 40h | 40h |
| 26 | 1.2.3.2.5 | Early Return |  | 5d | 2012-02-13 A | 2012-02-17 A |  | 100% |  |  | start no earlier than 2012-02-13 | Ross | 40h | 40h |
| 27 | 1.2.3.2.6 | Waiting List |  | 5d | 2012-02-13 A | 2012-02-17 A |  | 100% |  |  | start no earlier than 2012-02-13 | Janet | 40h | 40h |
| 28 | 1.2.3.2.7 | Front Desk |  | 5d | 2012-02-13 A | 2012-02-17 A |  | 100% |  |  | start no earlier than 2012-02-13 | Ross | 40h | 40h |
| 29 | 1.2.3.3 | Housing SISTIM Functionality on Housing |  | 8d | 2012-02-21 A | 2012-03-01 A |  | 100% |  |  | start no earlier than 2012-02-21 | Ross | 64h | 64h |
| 30 | 1.2.3.4 | Housing MITSIS Functionality on Housing |  | 8d | 2012-02-21 A | 2012-03-01 A |  | 100% |  |  | start no earlier than 2012-02-21 | Janet | 64h | 64h |

| ID | WBS | Task | Type | Duration | Start | Finish | Predecessors | Complete | Remaining | Total slack | Constraint | Resources | Work | Actual work |
| --- | --- | --- | --- | --- | --- | --- | --- | --- | --- | --- | --- | --- | --- | --- |
| 31 | 1.2.3.5 | **Housing Stakeholder - HFS Accounting (David Bull's Group)** |  | 5d | 2012-03-05 A | 2012-03-09 A | 30FS+1d | 100% |  |  |  |  | 240h | 240h |
| 32 | 1.2.3.5.1 | Discuss systems/applications/process flow |  | 5d | 2012-03-05 A | 2012-03-09 A |  | 100% |  |  |  | Janet | 40h | 40h |
| 33 | 1.2.3.5.2 | Discuss process calendar |  | 5d | 2012-03-05 A | 2012-03-09 A |  | 100% |  |  |  | Janet | 40h | 40h |
| 34 | 1.2.3.5.3 | Walkthrough of digital Building/Room Setup & Maintenance |  | 5d | 2012-03-05 A | 2012-03-09 A |  | 100% |  |  |  | Janet | 40h | 40h |
| 35 | 1.2.3.5.4 | Walkthrough of Room Rate Codes Setup & Maintenance |  | 5d | 2012-03-05 A | 2012-03-09 A |  | 100% |  |  |  | Janet | 40h | 40h |
| 36 | 1.2.3.5.5 | Analysis/review of OTF process |  | 5d | 2012-03-05 A | 2012-03-09 A |  | 100% |  |  |  | Janet | 40h | 40h |
| 37 | 1.2.3.5.6 | Discuss functionality/efficiency/information gaps in current assessment & OTF process |  | 5d | 2012-03-05 A | 2012-03-09 A |  | 100% |  |  |  | Janet | 40h | 40h |
| 38 | 1.2.3.6 | **Housing Stakeholder - Student Financial Services** |  | 5d | 2012-03-13 A | 2012-03-19 A | 31FS+1d | 100% |  |  |  |  | 48h | 48h |
| 39 | 1.2.3.6.1 | Assess primary users/roles |  | 5d | 2012-03-13 A | 2012-03-19 A |  | 100% |  |  |  | Ross [40%] | 16h | 16h |
| 40 | 1.2.3.6.2 | Discuss systems/process flow |  | 5d | 2012-03-13 A | 2012-03-19 A |  | 100% |  |  |  | Ross [40%] | 16h | 16h |
| 41 | 1.2.3.6.3 | Discuss process calendar |  | 5d | 2012-03-13 A | 2012-03-19 A |  | 100% |  |  |  | Ross [40%] | 16h | 16h |
| 42 | 1.2.3.7 | **Housing Stakeholder - Registrar** |  | 5d | 2012-03-21 A | 2012-03-27 A | 38FS+1d | 100% |  |  |  |  | 120h | 120h |
| 43 | 1.2.3.7.1 | Evaluate scope of affected data/process/systems |  | 5d | 2012-03-21 A | 2012-03-27 A |  | 100% |  |  |  | Janet | 40h | 40h |
| 44 | 1.2.3.7.2 | Examine dataflow for MITSIS Directory information |  | 5d | 2012-03-21 A | 2012-03-27 A |  | 100% |  |  |  | Janet | 40h | 40h |
| 45 | 1.2.3.7.3 | Examine current supporting processes & functionality |  | 5d | 2012-03-21 A | 2012-03-27 A |  | 100% |  |  |  | Janet | 40h | 40h |
| 46 | 1.2.3.8 | Housing Stakeholders - Card Office / SEMO I |  | 1d | 2012-03-23 A | 2012-03-23 A |  | 100% |  |  | start no earlier than 2012-03-23 | Ross [40%] | 3.2h | 3.2h |
| 47 | 1.2.3.9 | Housing Stakeholders - Campus Dining |  | 1d | 2012-04-04 A | 2012-04-04 A |  | 100% |  |  | start no earlier than 2012-04-04 | Ross [40%] | 3.2h | 3.2h |
| 48 | 1.2.3.10 | Housing Stakeholders - Tech Cash |  | 1d | 2012-04-04 A | 2012-04-04 A |  | 100% |  |  | start no earlier than 2012-04-04 | Janet [40%] | 3.2h | 3.2h |
| 49 | 1.2.3.11 | UG House Managers |  | 1d | 2012-04-12 A | 2012-04-12 A |  | 100% |  |  | start no earlier than 2012-04-12 | Ross [40%] | 3.2h | 3.2h |
| 50 | 1.2.3.12 | GRAD House Managers |  | 1d | 2012-04-17 A | 2012-04-17 A |  | 100% |  |  | start no earlier than 2012-04-17 | Janet [40%] | 3.2h | 3.2h |
| 51 | 1.2.3.13 | Housing Stakeholders - Card Office / SEMO II |  | 1d | 2012-04-23 A | 2012-04-23 A |  | 100% |  |  | start no earlier than 2012-04-23 | Janet | 8h | 8h |
| 52 | 1.2.3.14 | Dean On Call |  | 1d | 2012-05-09 | 2012-05-09 |  |  |  | 98d | start no earlier than 2012-05-09 |  |  |  |
| 53 | 1.2.3.15 | FSILG |  | 1d | 2012-05-15 | 2012-05-15 |  |  |  | 94d | start no earlier than 2012-05-15 | Janet [40%] | 3.2h |  |
| 54 | 1.2.4 | **Discovery Phase Documentation** |  | 77d | 2012-04-09 A | 2012-07-24 |  | 44% | 43.2d | 68d |  |  | 550.8h | 184.4h |
| 55 | 1.2.4.1 | **As-Is Business Process Descriptions** |  | 27d | 2012-04-09 A | 2012-05-16 |  | 97% | 0.84d | 118d |  |  | 139.2h | 115.2h |
| 56 | 1.2.4.1.1 | **Undergraduate Process** |  | 24d | 2012-04-09 A | 2012-05-11 |  | 99% | 0d | 97d |  |  | 49.6h | 49.6h |
| 57 | 1.2.4.1.1.1 | Undergraduate Process - Internal review |  | 15d | 2012-04-09 A | 2012-04-27 A |  | 100% |  |  | finish no earlier than 2012-04-27 | Ross [40%] | 48h | 48h |
| 58 | 1.2.4.1.1.2 | Present Undergraduate Draft Version to Project Sponsor |  | 1d | 2012-05-04 A | 2012-05-04 A | 57, 60 | 100% |  |  | finish no earlier than 2012-05-04 | Ross [20%] | 1.6h | 1.6h |
| 59 | 1.2.4.1.1.3 | Obtain approval from Project Sponsors | milestone | 0d | 2012-05-11 | 2012-05-11 | 58 |  |  | 97d | start no earlier than 2012-05-11 |  |  |  |

| ID | WBS | Task | Type | Duration | Start | Finish | Predecessors | Complete | Remaining | Total slack | Free slack | Constraint | Resources | Work | Actual work |
| --- | --- | --- | --- | --- | --- | --- | --- | --- | --- | --- | --- | --- | --- | --- | --- |
| 60 | 1.2.4.1.2 | **Graduate Process** |  | 27d | 2012-04-09 A | 2012-05-16 |  | 94% | 1.69d | 118d |  |  | Janet [40%] | 89.6h | 65.6h |
| 61 | 1.2.4.1.2.1 | Graduate Process - Internal review |  | 15d | 2012-04-09 A | 2012-04-27 A |  | 100% |  |  |  | start no earlier than 2012-04-09 | Janet [40%] | 48h | 48h |
| 62 | 1.2.4.1.2.2 | Present Graduate Draft Version to Project Sponsor |  | 1d | 2012-05-09 | 2012-05-09 | 61 |  |  | 98d | 0d | start no earlier than 2012-05-09 | Janet [40%] | 3.2h |  |
| 63 | 1.2.4.1.2.3 | Obtain approval from Project Sponsors | milestone | 0d | 2012-05-16 | 2012-05-16 | 62 |  |  | 118d |  | start no earlier than 2012-05-16 | Janet [40%] |  |  |
| 64 | 1.2.4.1.3 | As-Is Busines Process Documentation completed | milestone | 0d | 2012-05-09 | 2012-05-09 | 62, 58 |  |  | 122d |  |  | Ross [40%]; Janet [40%] |  |  |
| 65 | 1.2.4.2 | **As-Is Process Maps (Visual Micrografx Process Maps)** |  | 31d | 2012-05-07 A | 2012-06-18 | 58 | 17% | 25.73d | 0d |  |  |  | 147.2h | 21.76h |
| 66 | 1.2.4.2.1 | Graduate Students - Internal review |  | 17d | 2012-05-07 A | 2012-05-29 |  | 20% | 13.6d | 14d |  | finish no earlier than 2012-05-24 | Janet [40%] | 54.4h | 10.88h |
| 67 | 1.2.4.2.2 | Undergraduate Students |  | 17d | 2012-05-07 A | 2012-05-29 |  | 20% | 13.6d | 14d |  | finish no earlier than 2012-05-24 | Ross [40%] | 54.4h | 10.88h |
| 68 | 1.2.4.2.3 | Present Draft Versions to Project Sponsor |  | 1d | 2012-06-11 | 2012-06-11 |  |  |  | 0d |  | start no earlier than 2012-06-11 | Janet [40%]; Ross [40%] | 6.4h |  |
| 69 | 1.2.4.2.4 | Updated completed versions after feedback from Project Sponsors |  | 5d | 2012-06-12 | 2012-06-18 | 68 |  |  | 0d |  | start no earlier than 2012-05-29 | Janet [40%]; Ross [40%] | 32h |  |
| 70 | 1.2.4.2.5 | As-Is Process Maps completed | milestone | 0d | 2012-06-18 | 2012-06-18 | 69 |  |  | 0d |  |  |  |  |  |
| 71 | 1.2.4.3 | **System Diagram (IS&T)** |  | 39d | 2012-05-31 A | 2012-07-24 | 65 | 30% | 27.13d | 0d |  |  | Ross [44%] | 264.4h | 47.44h |
| 72 | 1.2.4.3.1 | High Level Picture |  | 20d | 2012-05-31 A | 2012-07-02 |  | 50% | 10d | 16d |  |  | Ross [40%] | 64h | 32h |
| 73 | 1.2.4.3.2 | Details - with Feeds, Interfaces, |  | 20d | 2012-06-19 A | 2012-07-16 |  | 20% | 16d | 0d |  |  | Ross [40%] | 64h | 12.8h |
| 74 | 1.2.4.3.3 | Present Draft Versions to Project Sponsor |  | 1d | 2012-07-17 | 2012-07-17 | 73 |  |  | 0d |  |  |  |  |  |
| 75 | 1.2.4.3.4 | Updated completed versions after feedback from Project Sponsors |  | 5d | 2012-07-18 | 2012-07-24 | 74 |  |  | 0d |  |  |  |  |  |
| 76 | 1.2.4.3.5 | As-Is System Diagram completed | milestone | 0d | 2012-07-24 | 2012-07-24 | 75 |  |  | 0d |  |  |  |  |  |
| 77 | 1.2.5 | Review with Project Team, Stakeholders |  | 3d | 2012-07-25 | 2012-07-27 | 71 |  |  | 0d |  |  |  |  |  |
| 78 | 1.2.6 | Discovery Phase Completed | milestone | 0d | 2012-07-27 | 2012-07-27 | 77 |  |  | 0d |  |  |  |  |  |
| 79 | 1.3 | **Define Phase** |  | 63d | 2012-07-02 | 2012-09-26 | 78FS-20d |  |  | 0d |  |  |  | 2913.6h |  |
| 80 | 1.3.1 | **Identify stakeholder needs** |  | 20d | 2012-07-02 | 2012-07-27 |  |  |  | 0d |  |  |  | 1536h |  |
| 81 | 1.3.1.1 | Housing Central Office |  | 20d | 2012-07-02 | 2012-07-27 |  |  |  | 0d |  |  | Ross [40%]; Janet [40%] | 128h |  |
| 82 | 1.3.1.2 | Housing Managers |  | 20d | 2012-07-02 | 2012-07-27 |  |  |  | 0d |  |  | Ross [40%]; Janet [40%] | 128h |  |
| 83 | 1.3.1.3 | Housing Lottery |  | 20d | 2012-07-02 | 2012-07-27 |  |  |  | 0d |  |  | Ross [40%]; Janet [40%] | 128h |  |
| 84 | 1.3.1.4 | Housing Filemaker datbases |  | 20d | 2012-07-02 | 2012-07-27 |  |  |  | 0d |  |  | Ross [40%]; Janet [40%] | 128h |  |
| 85 | 1.3.1.5 | Undergraduate Housing |  | 20d | 2012-07-02 | 2012-07-27 |  |  |  | 0d |  |  | Ross [40%]; Janet [40%] | 128h |  |
| 86 | 1.3.1.6 | Graduate Housing |  | 20d | 2012-07-02 | 2012-07-27 |  |  |  | 0d |  |  | Ross [40%]; Janet [40%] | 128h |  |
| 87 | 1.3.1.7 | SFS |  | 20d | 2012-07-02 | 2012-07-27 |  |  |  | 0d |  |  | Ross [40%]; Janet [40%] | 128h |  |
| 88 | 1.3.1.8 | HFS |  | 20d | 2012-07-02 | 2012-07-27 |  |  |  | 0d |  |  | Ross [40%]; Janet [40%] | 128h |  |
| 89 | 1.3.1.9 | SEMO / Card Access |  | 20d | 2012-07-02 | 2012-07-27 |  |  |  | 0d |  |  | Ross [40%]; Janet [40%] | 128h |  |
| 90 | 1.3.1.10 | Campus Dining / Tech Cash |  | 20d | 2012-07-02 | 2012-07-27 |  |  |  | 0d |  |  | Ross [40%]; Janet [40%] | 128h |  |
| 91 | 1.3.1.11 | Deans on Call |  | 20d | 2012-07-02 | 2012-07-27 |  |  |  | 0d |  |  | Ross [40%]; Janet [40%] | 128h |  |
| 92 | 1.3.1.12 | FSILG |  | 20d | 2012-07-02 | 2012-07-27 |  |  |  | 0d |  |  | Ross [40%]; Janet [40%] | 128h |  |

Notes:
- 65: Need to show calendar and stakeholders

| ID | WBS | Task | Duration | Start | Finish | Predecessors | Total slack | Free slack | Resources | Work |
| --- | --- | --- | --- | --- | --- | --- | --- | --- | --- | --- |
| 93 | 1.3.2 | **Review CBORD capabilities** | 15d | 2012-07-30 | 2012-08-17 | 80 | 0d |  | Ross [40%]; Janet [40%] | 224h |
| 94 | 1.3.2.1 | Review as-is of CBORD Odyssey today | 5d | 2012-07-30 | 2012-08-03 |  | 0d |  | Ross [40%]; Janet [40%] | 32h |
| 95 | 1.3.2.2 | Review where it can replace manual processes | 5d | 2012-08-06 | 2012-08-10 | 94 | 0d |  | Ross [40%]; Janet [40%] | 32h |
| 96 | 1.3.2.3 | Review as-is integration points | 5d | 2012-08-13 | 2012-08-17 | 95 | 0d |  | Ross [40%]; Janet [40%] | 32h |
| 97 | 1.3.2.4 | Training, Site-visit | 5d | 2012-07-30 | 2012-08-03 |  | 10d |  | Ross [40%]; Janet [40%] | 32h |
| 98 | 1.3.3 | **Out of Stakeholder Needs, Identify functional Specifications** | 12d | 2012-08-20 | 2012-09-04 | 93 | 22d | 0d | Ross [40%]; Janet [40%] | 998.4h |
| 99 | 1.3.3.1 | Housing Central Office | 12d | 2012-08-20 | 2012-09-04 |  | 22d |  | Ross [40%]; Janet [40%] | 76.8h |
| 100 | 1.3.3.2 | Housing Managers | 12d | 2012-08-20 | 2012-09-04 |  | 22d |  | Ross [40%]; Janet [40%] | 76.8h |
| 101 | 1.3.3.3 | Housing Lottery | 12d | 2012-08-20 | 2012-09-04 |  | 22d |  | Ross [40%]; Janet [40%] | 76.8h |
| 102 | 1.3.3.4 | Housing Filemaker datbases | 12d | 2012-08-20 | 2012-09-04 |  | 22d |  | Ross [40%]; Janet [40%] | 76.8h |
| 103 | 1.3.3.5 | Undergraduate Housing | 12d | 2012-08-20 | 2012-09-04 |  | 22d |  | Ross [40%]; Janet [40%] | 76.8h |
| 104 | 1.3.3.6 | Graduate Housing | 12d | 2012-08-20 | 2012-09-04 |  | 22d |  | Ross [40%]; Janet [40%] | 76.8h |
| 105 | 1.3.3.7 | SFS | 12d | 2012-08-20 | 2012-09-04 |  | 22d |  | Ross [40%]; Janet [40%] | 76.8h |
| 106 | 1.3.3.8 | HFS | 12d | 2012-08-20 | 2012-09-04 |  | 22d |  | Ross [40%]; Janet [40%] | 76.8h |
| 107 | 1.3.3.9 | SEMO / Card Access | 12d | 2012-08-20 | 2012-09-04 |  | 22d |  | Ross [40%]; Janet [40%] | 76.8h |
| 108 | 1.3.3.10 | Campus Dining / Tech Cash | 12d | 2012-08-20 | 2012-09-04 |  | 22d |  | Ross [40%]; Janet [40%] | 76.8h |
| 109 | 1.3.3.11 | Deans on Call | 12d | 2012-08-20 | 2012-09-04 |  | 22d |  | Ross [40%]; Janet [40%] | 76.8h |
| 110 | 1.3.3.12 | FSILG | 12d | 2012-08-20 | 2012-09-04 |  | 22d |  | Ross [40%]; Janet [40%] | 76.8h |
| 111 | 1.3.4 | Build wireframes | 5d | 2012-09-05 | 2012-09-11 | 98 | 22d | 0d | Ross [40%]; Janet [40%] | 32h |
| 112 | 1.3.5 | Create Functional Specifications | 5d | 2012-09-12 | 2012-09-18 | 111 | 22d | 0d | Ross; Janet [40%] | 56h |
| 113 | 1.3.6 | Review functionality with all stakeholders | 5d | 2012-09-19 | 2012-09-25 | 112 | 22d | 0d | Ross; Janet [40%] | 56h |
| 114 | 1.3.7 | Obtain approval from all stakeholders | 1d | 2012-09-26 | 2012-09-26 | 113 | 22d |  | Ross; Janet [40%] | 11.2h |
| 115 | 1.4 | Design Phase | 50d | 2012-08-20 | 2012-10-26 | 93 | 0d |  |  |  |
